# ZTF telescope changeover work plan_V7

Schedule from MS Project, 2017-03-01 to 2017-09-27.

## Calendars

- Standard: Mon-Fri 08:00-12:00, 13:00-17:00; Sat-Sun off. Exceptions (off unless hours are given): 2017-05-29 (Memorial Day), 2017-07-03 to 2017-07-04 (Independence Day Holiday), 2017-09-04 (Labor Day).

## Schedule

| ID | WBS | Task | Type | Duration | Start | Finish | Predecessors | Total slack | Free slack | Constraint |
| --- | --- | --- | --- | --- | --- | --- | --- | --- | --- | --- |
| 1 | 1 | **PTF/ZTF Changeover** |  | 147d | 2017-03-01 | 2017-09-27 |  | 0d |  | start no earlier than 2017-03-01 |
| 2 | 1.1 | PTF camera & e-rack removal |  | 2d | 2017-03-01 | 2017-03-02 |  | 60d | 0d | start no earlier than 2017-03-01 |
| 3 | 1.2 | Primary mirror removal |  | 1d | 2017-03-03 | 2017-03-03 | 2 | 60d | 0d |  |
| 4 | 1.3 | Dummy mirror install |  | 0.5d | 2017-03-06 | 2017-03-06 | 3 | 60d | 0d |  |
| 5 | 1.4 | Remove shutter & baffle |  | 0.5d | 2017-03-06 | 2017-03-06 | 4 | 60d | 0d |  |
| 6 | 1.5 | Doublet ass'y removal and balance |  | 0.5d | 2017-03-07 | 2017-03-07 | 5 | 60d | 0d |  |
| 7 | 1.6 | Remove focus hub and spiders |  | 1.5d | 2017-03-07 | 2017-03-08 | 6 | 60d | 0d |  |
| 8 | 1.7 | TCS Testing |  | 2d | 2017-03-09 | 2017-03-10 | 7 | 60d | 0d |  |
| 9 | 1.8 | Doublet optics removal from cell |  | 1d | 2017-03-08 | 2017-03-09 | 6FS+1d | 122.5d | 0d |  |
| 10 | 1.9 | Doublet cell clean and replate |  | 3w | 2017-03-09 | 2017-03-30 | 9 | 122.5d | 0d |  |
| 11 | 1.10 | Grounding & lightning protection upgrade |  | 3w | 2017-03-16 | 2017-04-05 | 8FS+3d | 124d |  |  |
| 12 | 1.11 | Dome power rewiring |  | 3d | 2017-03-15 | 2017-03-17 | 8FS+2d | 137d |  |  |
| 13 | 1.12 | Doublet cell/optics assembly |  | 3d | 2017-04-04 | 2017-04-07 | 10FS+3d | 122.5d |  |  |
| 14 | 1.13 | Enlarge access hatch in tube |  | 3d | 2017-03-14 | 2017-03-16 | 8FS+1d | 60d | 0d |  |
| 15 | 1.14 | Cut CCD cable port holes in tube |  | 1d | 2017-03-17 | 2017-03-17 | 14 | 60d | 0d |  |
| 16 | 1.15 | Add primary end c'wgt mounts |  | 1d | 2017-03-20 | 2017-03-20 | 15 | 60d | 0d |  |
| 17 | 1.16 | Remove South Finder Scope |  | 1d | 2017-03-21 | 2017-03-21 | 16 | 60d | 0d |  |
| 18 | 1.17 | Add elect. rack mtg features to tube |  | 0.5d | 2017-03-22 | 2017-03-22 | 17 | 134.5d |  |  |
| 19 | 1.18 | Add filter exchanger mount features |  | 1d | 2017-03-22 | 2017-03-22 | 17 | 60d | 0d |  |
| 20 | 1.19 | ZTF ICS and TCS testing |  | 3d | 2017-03-23 | 2017-03-27 | 19 | 131d |  |  |
| 21 | 1.20 | Clean, prep and paint tube inside |  | 6d | 2017-03-24 | 2017-03-31 | 19FS+1d | 60d | 0d |  |
| 22 | 1.21 | Primary re-aluminize |  | 5d | 2017-04-10 | 2017-04-14 | 21FS+5d | 117d |  |  |
| 23 | 1.22 | Install instrument support assy/hexapod |  | 3d | 2017-04-04 | 2017-04-06 | 21FS+1d | 60d | 0d |  |
| 24 | 1.23 | Cable routing & mgt system install (prelim) |  | 2d | 2017-04-07 | 2017-04-10 | 23 | 60d | 0d |  |
| 25 | 1.24 | Install doublet & shutter |  | 2d | 2017-04-11 | 2017-04-12 | 24 | 60d | 0d |  |
| 26 | 1.25 | Dry air system testing (prelim) |  | 2d | 2017-04-13 | 2017-04-14 | 25 | 60d | 0d |  |
| 27 | 1.26 | TCS Testing |  | 2d | 2017-04-17 | 2017-04-18 | 26 | 60d | 0d |  |
| 28 | 1.27 | Install and align primary mirror |  | 2d | 2017-04-20 | 2017-04-21 | 27FS+1d | 60d | 0d |  |
| 29 | 1.28 | ZTF camera transport to summit | milestone | 0d | 2017-04-24 | 2017-04-24 | 28FS+1d | 60d | 0d |  |
| 30 | 1.29 | Install Cryotiger lines & cabling |  | 1d | 2017-04-26 | 2017-04-26 | 29FS+1d | 106d |  |  |
| 31 | 1.30 | Initial installation of ZTF camera |  | 3d | 2017-04-25 | 2017-04-27 | 29 | 105d |  |  |
| 32 | 1.31 | Install e-rack & connect glycol plumbing |  | 2d | 2017-04-26 | 2017-04-27 | 29FS+1d | 60d | 0d |  |
| 33 | 1.32 | ZTF camera functional verification |  | 2d | 2017-04-28 | 2017-05-01 | 32 | 60d | 0d |  |
| 34 | 1.33 | ZTF Camera Alignment Testing | milestone | 0d | 2017-05-01 | 2017-05-01 | 33 | 103d |  |  |
| 35 | 1.34 | ZTF Camera Alignment Testing |  | 10d | 2017-05-02 | 2017-05-15 | 33 | 60d | 0d |  |
| 36 | 1.35 | ZTF camera and cabling removal |  | 2d | 2017-05-16 | 2017-05-17 | 35 | 60d | 0d |  |
| 37 | 1.36 | Install testing c'wgts & camera surrogate |  | 2d | 2017-05-18 | 2017-05-19 | 36 | 60d | 0d |  |
| 38 | 1.37 | Telescope drive & TCS testing |  | 5d | 2017-05-23 | 2017-05-30 | 37FS+1d | 60d | 0d |  |
| 39 | 1.38 | Filter exchanger testing |  | 10d | 2017-05-31 | 2017-06-13 | 38 | 60d | 0d |  |
| 40 | 1.39 | Wind screen improvements |  | 3d | 2017-06-14 | 2017-06-16 | 39 | 60d | 0d |  |
| 41 | 1.40 | Enviornmental sensor installation |  | 2d | 2017-06-15 | 2017-06-16 | 39FS+1d | 70d |  |  |
| 42 | 1.41 | RA Worm Bearing Adjustment |  | 2d | 2017-06-19 | 2017-06-20 | 40 | 60d | 0d |  |
| 43 | 1.42 | Cable and hose routing (finalize) |  | 2d | 2017-06-23 | 2017-06-26 | 42FS+2d | 60d | 0d |  |
| 44 | 1.43 | Air treatment system (final install & testing) |  | 3d | 2017-06-27 | 2017-06-29 | 43 | 60d | 0d |  |
| 45 | 1.44 | Baffle Installation |  | 1d | 2017-06-30 | 2017-06-30 | 44 | 60d |  |  |
| 46 | 1.45 | Trim plate delivery | milestone | 0d | 2017-07-17 | 2017-07-17 |  | 52d |  | start no earlier than 2017-07-17 |
| 47 | 1.46 | ZTF trim plate install & c'wgt adjust |  | 1d | 2017-08-01 | 2017-08-01 |  | 0d |  | start no earlier than 2017-08-01 |
| 48 | 1.47 | ZTF camera reinstall |  | 3d | 2017-07-28 | 2017-08-01 | 47SF+1d | 0d |  |  |
| 49 | 1.48 | ZTF First Light | milestone | 0d | 2017-08-01 | 2017-08-01 | 48 | 0d |  |  |
| 50 | 1.49 | Camera, filter exchanger engineering check-out incl. DIQ verification, scattered light eval.) |  | 5d | 2017-08-02 | 2017-08-08 | 49 | 0d |  |  |
| 51 | 1.50 | Full robotic operations check-out (open/close, weather interrupts, fault recovery, queue I/F, safety) |  | 15d | 2017-08-09 | 2017-08-29 | 50 | 0d |  |  |
| 52 | 1.51 | Operational efficiency optimization |  | 10d | 2017-08-23 | 2017-09-06 | 51FS-5d | 0d |  |  |
| 53 | 1.52 | Engineering contingency |  | 15d | 2017-09-07 | 2017-09-27 | 52 | 0d |  |  |
| 54 | 1.53 | Begin ZTF Science Verification | milestone | 0d | 2017-09-27 | 2017-09-27 | 53 | 0d |  |  |
